# progetto senza legami tra le attività

Schedule from MS Project, 2014-01-01 to 2014-02-26.

## Calendars

- Standard: Mon-Fri 08:00-12:00, 13:00-17:00; Sat-Sun off.

## Schedule

| ID | WBS | Task | Type | Duration | Start | Finish | Predecessors | Total slack |
| --- | --- | --- | --- | --- | --- | --- | --- | --- |
| 1 | 1 | **Progettazione e preliminari** |  | 8d | 2014-01-01 | 2014-01-10 |  | 0d |
| 2 | 1.1 | Contattare l'architetto |  | 1d | 2014-01-01 | 2014-01-01 |  | 0d |
| 3 | 1.2 | Concordare il progetto |  | 5d | 2014-01-02 | 2014-01-08 | 2 | 0d |
| 4 | 1.3 | Svuotare l’ufficio di tutti gli arredi, documenti, incartamenti, ... |  | 2d | 2014-01-09 | 2014-01-10 | 3 | 0d |
| 5 | 2 | **Esecuzione lavori** |  | 20.5d | 2014-01-13 | 2014-02-10 | 1 | 0d |
| 6 | 2.1 | Opere murarie |  | 15d | 2014-01-13 | 2014-01-31 |  | 0d |
| 7 | 2.2 | Impianto idraulico |  | 6d | 2014-01-20 | 2014-01-27 | 6SS+5d | 9d |
| 8 | 2.3 | Impianto elettrico |  | 5d | 2014-02-03 | 2014-02-07 | 6 | 0d |
| 9 | 2.4 | Impianto di climatizzazione |  | 5d | 2014-02-03 | 2014-02-07 | 6 | 0d |
| 10 | 2.5 | Impianto di telecomunicazioni |  | 2d | 2014-02-03 | 2014-02-04 | 6 | 3d |
| 11 | 2.6 | consegna lavori edili | milestone | 0.5d | 2014-02-10 | 2014-02-10 | 6, 7, 8, 9, 10 | 0d |
| 12 | 3 | **Rifiniture** |  | 11d | 2014-02-10 | 2014-02-25 | 5 | 0d |
| 13 | 3.1 | Contattare arredatore |  | 1d | 2014-02-10 | 2014-02-11 |  | 0d |
| 14 | 3.2 | Scegliere ed ordinare nuovi arredi |  | 2d | 2014-02-11 | 2014-02-13 | 13 | 0d |
| 15 | 3.3 | Mettere in opera i nuovi arredi |  | 3d | 2014-02-13 | 2014-02-18 | 14 | 0d |
| 16 | 3.4 | Installare telefoni, fax, computer |  | 2d | 2014-02-18 | 2014-02-20 | 15 | 0d |
| 17 | 3.5 | Disimballare documenti ed incartamenti |  | 3d | 2014-02-20 | 2014-02-25 | 16 | 0d |
| 18 | 4 | Ripresa attività lavorativa normale | milestone | 1d | 2014-02-25 | 2014-02-26 | 17 | 0d |
