# Ristrutturazione ufficio rag. Rossi

Schedule from MS Project, 2014-01-01 to 2014-02-17, costs in €.

## Calendars

- Standard: Mon-Fri 08:00-12:00, 13:00-17:00; Sat-Sun off.

## Resources

| Resource | Rate | Cost per use |
| --- | --- | --- |
| Rag. Rossi |  |  |
| Architetto | 100 |  |
| Segretaria rag. Rossi | 50 |  |
| Trasportatore | 50 | 50 |
| Muratore | 50 |  |
| Idraulico | 50 | 50 |
| Elettricista | 50 | 50 |
| Arredatore | 50 |  |

## Schedule

| ID | WBS | Task | Type | Duration | Start | Finish | Predecessors | Total slack | Resources | Work | Cost |
| --- | --- | --- | --- | --- | --- | --- | --- | --- | --- | --- | --- |
| 1 | 1 | **Progettazione e preliminari** |  | 8.5d | 2014-01-01 | 2014-01-13 |  | 0d |  | 150h | 7,850 |
| 2 | 1.1 | Contattare l'architetto |  | 0.5d | 2014-01-01 | 2014-01-01 |  | 0d | Segretaria rag. Rossi | 4h | 200 |
| 3 | 1.2 | Concordare il progetto |  | 5d | 2014-01-01 | 2014-01-08 | 2 | 0d | Rag. Rossi; Architetto | 80h | 4,000 |
| 4 | 1.3 | Svuotare l’ufficio di tutti gli arredi, documenti, incartamenti, ... |  | 3d | 2014-01-08 | 2014-01-13 | 3 | 0d | Trasportatore; Segretaria rag. Rossi [50%]; Muratore; Architetto [25%] | 66h | 3,650 |
| 5 | 2 | **Esecuzione lavori** |  | 17.5d | 2014-01-13 | 2014-02-05 | 1 | 0d |  | 276h | 24,015,200 |
| 6 | 2.1 | Opere murarie |  | 12d | 2014-01-13 | 2014-01-29 |  | 0d | Muratore; Architetto [25%] | 120h | 10,007,200 |
| 7 | 2.2 | Impianto idraulico |  | 6d | 2014-01-20 | 2014-01-28 | 6SS+5d | 6d | Idraulico | 48h | 5,002,450 |
| 8 | 2.3 | Impianto elettrico |  | 5d | 2014-01-29 | 2014-02-05 | 6 | 0d | Elettricista | 40h | 2,002,050 |
| 9 | 2.4 | Impianto di climatizzazione |  | 5d | 2014-01-29 | 2014-02-05 | 6 | 0d | Idraulico | 40h | 5,002,050 |
| 10 | 2.5 | Impianto di telecomunicazioni |  | 2d | 2014-01-29 | 2014-01-31 | 6 | 3d | Elettricista | 16h | 2,000,850 |
| 11 | 2.6 | consegna lavori edili | milestone | 0.5d | 2014-02-05 | 2014-02-05 | 6, 7, 8, 9, 10 | 0d | Muratore; Architetto; Rag. Rossi | 12h | 600 |
| 12 | 3 | **Rifiniture** |  | 7.5d | 2014-02-06 | 2014-02-17 | 5 | 0d |  | 88h | 15,004,150 |
| 13 | 3.1 | Contattare arredatore |  | 1d | 2014-02-06 | 2014-02-06 |  | 0d | Segretaria rag. Rossi | 8h | 400 |
| 14 | 3.2 | Scegliere ed ordinare nuovi arredi |  | 1d | 2014-02-07 | 2014-02-07 | 13 | 0d | Rag. Rossi; Arredatore | 16h | 15,000,400 |
| 15 | 3.3 | Mettere in opera i nuovi arredi |  | 2d | 2014-02-10 | 2014-02-11 | 14 | 0d | Trasportatore; Arredatore [50%] | 24h | 1,250 |
| 16 | 3.4 | Installare telefoni, fax, computer |  | 2d | 2014-02-12 | 2014-02-13 | 15 | 0d | Elettricista | 16h | 850 |
| 17 | 3.5 | Disimballare documenti ed incartamenti |  | 1.5d | 2014-02-14 | 2014-02-17 | 16 | 0d | Trasportatore; Segretaria rag. Rossi | 24h | 1,250 |
| 18 | 4 | Ripresa attività lavorativa normale | milestone | 0.5d | 2014-02-17 | 2014-02-17 | 17 | 0d | Segretaria rag. Rossi; Rag. Rossi | 8h | 200 |
