# Ristrutturazione ufficio rag. Rossi

Schedule from MS Project, 2014-01-01 to 2014-02-17, costs in €.

## Calendars

- Standard: Mon-Fri 08:00-12:00, 13:00-17:00; Sat-Sun off.

## Resources

| Resource | Rate | Cost per use |
| --- | --- | --- |
| Rag. Rossi |  |  |
| Architetto | 100 |  |
| Segretaria rag. Rossi | 50 |  |
| Trasportatore | 50 | 50 |
| Muratore | 50 |  |
| Idraulico | 50 | 50 |
| Elettricista | 50 | 50 |
| Arredatore | 50 |  |

## Schedule

| ID | WBS | Task | Type | Duration | Start | Finish | Predecessors | Baseline start | Baseline finish | Baseline duration | Total slack | Resources | Work | Cost | Baseline cost |
| --- | --- | --- | --- | --- | --- | --- | --- | --- | --- | --- | --- | --- | --- | --- | --- |
| 1 | 1 | **Progettazione e preliminari** |  | 8.5d | 2014-01-01 | 2014-01-13 |  | 1999-02-19 | 1999-03-03 | 8.5d | 0d |  | 150h | 7,850 | 7,850,000 |
| 2 | 1.1 | Contattare l'architetto |  | 0.5d | 2014-01-01 | 2014-01-01 |  | 1999-02-19 | 1999-02-19 | 0.5d | 0d | Segretaria rag. Rossi | 4h | 200 | 200,000 |
| 3 | 1.2 | Concordare il progetto |  | 5d | 2014-01-01 | 2014-01-08 | 2 | 1999-02-19 | 1999-02-26 | 5d | 0d | Rag. Rossi; Architetto | 80h | 4,000 | 4,000,000 |
| 4 | 1.3 | Svuotare l’ufficio di tutti gli arredi, documenti, incartamenti, ... |  | 3d | 2014-01-08 | 2014-01-13 | 3 | 1999-02-26 | 1999-03-03 | 3d | 0d | Trasportatore; Segretaria rag. Rossi [50%]; Muratore; Architetto [25%] | 66h | 3,650 | 3,650,000 |
| 5 | 2 | **Esecuzione lavori** |  | 17.5d | 2014-01-13 | 2014-02-05 | 1 | 1999-03-03 | 1999-03-26 | 17.5d | 0d |  | 276h | 24,015,200 | 39,200,000 |
| 6 | 2.1 | Opere murarie |  | 12d | 2014-01-13 | 2014-01-29 |  | 1999-03-03 | 1999-03-19 | 12d | 0d | Muratore; Architetto [25%] | 120h | 10,007,200 | 17,200,000 |
| 7 | 2.2 | Impianto idraulico |  | 6d | 2014-01-20 | 2014-01-28 | 6SS+5d | 1999-03-10 | 1999-03-18 | 6d | 6d | Idraulico | 48h | 5,002,450 | 7,450,000 |
| 8 | 2.3 | Impianto elettrico |  | 5d | 2014-01-29 | 2014-02-05 | 6 | 1999-03-19 | 1999-03-26 | 5d | 0d | Elettricista | 40h | 2,002,050 | 4,050,000 |
| 9 | 2.4 | Impianto di climatizzazione |  | 5d | 2014-01-29 | 2014-02-05 | 6 | 1999-03-19 | 1999-03-26 | 5d | 0d | Idraulico | 40h | 5,002,050 | 7,050,000 |
| 10 | 2.5 | Impianto di telecomunicazioni |  | 2d | 2014-01-29 | 2014-01-31 | 6 | 1999-03-19 | 1999-03-23 | 2d | 3d | Elettricista | 16h | 2,000,850 | 2,850,000 |
| 11 | 2.6 | consegna lavori edili | milestone | 0.5d | 2014-02-05 | 2014-02-05 | 6, 7, 8, 9, 10 | 1999-03-26 | 1999-03-26 | 0.5d | 0d | Muratore; Architetto; Rag. Rossi | 12h | 600 | 600,000 |
| 12 | 3 | **Rifiniture** |  | 7.5d | 2014-02-06 | 2014-02-17 | 5 | 1999-03-29 | 1999-04-07 | 7.5d | 0d |  | 88h | 15,004,150 | 19,150,000 |
| 13 | 3.1 | Contattare arredatore |  | 1d | 2014-02-06 | 2014-02-06 |  | 1999-03-29 | 1999-03-29 | 1d | 0d | Segretaria rag. Rossi | 8h | 400 | 400,000 |
| 14 | 3.2 | Scegliere ed ordinare nuovi arredi |  | 1d | 2014-02-07 | 2014-02-07 | 13 | 1999-03-30 | 1999-03-30 | 1d | 0d | Rag. Rossi; Arredatore | 16h | 15,000,400 | 15,400,000 |
| 15 | 3.3 | Mettere in opera i nuovi arredi |  | 2d | 2014-02-10 | 2014-02-11 | 14 | 1999-03-31 | 1999-04-01 | 2d | 0d | Trasportatore; Arredatore [50%] | 24h | 1,250 | 1,250,000 |
| 16 | 3.4 | Installare telefoni, fax, computer |  | 2d | 2014-02-12 | 2014-02-13 | 15 | 1999-04-02 | 1999-04-05 | 2d | 0d | Elettricista | 16h | 850 | 850,000 |
| 17 | 3.5 | Disimballare documenti ed incartamenti |  | 1.5d | 2014-02-14 | 2014-02-17 | 16 | 1999-04-06 | 1999-04-07 | 1.5d | 0d | Trasportatore; Segretaria rag. Rossi | 24h | 1,250 | 1,250,000 |
| 18 | 4 | Ripresa attività lavorativa normale | milestone | 0.5d | 2014-02-17 | 2014-02-17 | 17 | 1999-04-07 | 1999-04-07 | 0.5d | 0d | Segretaria rag. Rossi; Rag. Rossi | 8h | 200 | 200,000 |
